# PSD电性件

Schedule from MS Project, 2026-03-17 to 2026-12-27, A marks actual dates.

## Calendars

- 7天全周工作日: Mon-Sun 08:00-12:00, 13:00-17:00. Exceptions (off unless hours are given): 2026-06-07 08:00-12:00, 13:00-17:00.

## Schedule

| ID | WBS | Task | Type | Duration | Start | Finish | Predecessors | Complete | Remaining | Total slack | Free slack |
| --- | --- | --- | --- | --- | --- | --- | --- | --- | --- | --- | --- |
| 1 | 1 | **PSD电性件** |  | 186d? | 2026-03-30 A | 2026-10-01 |  | 25% | 139.61d? | 87d |  |
| 2 | 1.1 | **SiPM板** |  | 76d? | 2026-05-26 A | 2026-08-09 |  | 45% | 41.97d? | 117d | 30d |
| 3 | 1.1.1 | 无锡同步布局布线 | manual | 30d | 2026-05-26 A | 2026-07-03 A |  | 100% |  |  |  |
| 4 | 1.1.2 | 投产评审 |  | 7d? | 2026-07-04 | 2026-07-10 | 3 |  |  | 117d | 0d |
| 5 | 1.1.3 | PCB制板 |  | 20d? | 2026-07-11 | 2026-07-30 | 4 |  |  | 117d | 0d |
| 6 | 1.1.4 | SiPM板电装 |  | 10d | 2026-07-31 | 2026-08-09 | 5 |  |  | 117d |  |
| 7 | 1.2 | **顶面Ebox01-FEB设计与制板** |  | 96d? | 2026-06-01 A | 2026-09-04 |  | 32% | 65.1d? | 91d | 4d |
| 8 | 1.2.1 | 原理图更新 | manual | 28d | 2026-06-01 A | 2026-07-07 A |  | 100% |  |  |  |
| 9 | 1.2.2 | 无锡同步布局布线 |  | 30d? | 2026-07-08 | 2026-08-06 | 8 |  |  | 91d | 0d |
| 10 | 1.2.3 | 投产评审 |  | 4d? | 2026-08-07 | 2026-08-10 | 9 |  |  | 91d | 0d |
| 11 | 1.2.4 | PCB制板 |  | 20d? | 2026-08-11 | 2026-08-30 | 10 |  |  | 91d | 0d |
| 12 | 1.2.5 | 电装 |  | 5d? | 2026-08-31 | 2026-09-04 | 11 |  |  | 91d |  |
| 13 | 1.3 | **顶面Ebox01-MB1/2设计与制板** |  | 98d? | 2026-06-01 | 2026-09-06 |  |  |  | 0d |  |
| 14 | 1.3.1 | 原理图更新 | manual | 45d? | 2026-06-01 | 2026-07-15 |  |  |  |  |  |
| 15 | 1.3.2 | 布局布线 |  | 30d? | 2026-07-16 | 2026-08-14 | 14 |  |  | 89d | 0d |
| 16 | 1.3.3 | 投产评审 |  | 1d | 2026-08-15 | 2026-08-15 | 15 |  |  | 89d | 0d |
| 17 | 1.3.4 | PCB制板 |  | 20d? | 2026-08-16 | 2026-09-04 | 16 |  |  | 89d | 0d |
| 18 | 1.3.5 | 电装 |  | 2d? | 2026-09-05 | 2026-09-06 | 17 |  |  | 89d |  |
| 19 | 1.4 | **顶面Ebox01-电源设计与制板** |  | 97d? | 2026-06-01 A | 2026-09-05 |  | 36% | 62.51d? | 90d | 3d |
| 20 | 1.4.1 | 原理图更新 | manual | 32d | 2026-06-01 A | 2026-07-09 A |  | 100% |  |  |  |
| 21 | 1.4.2 | 无锡同步布局布线 |  | 30d? | 2026-07-10 | 2026-08-08 | 20 |  |  | 90d | 0d |
| 22 | 1.4.3 | 投产评审 |  | 3d? | 2026-08-09 | 2026-08-11 | 21 |  |  | 90d | 0d |
| 23 | 1.4.4 | PCB制板 |  | 20d? | 2026-08-12 | 2026-08-31 | 22 |  |  | 90d | 0d |
| 24 | 1.4.5 | 电装 |  | 5d | 2026-09-01 | 2026-09-05 | 23 |  |  | 90d |  |

Notes:
- 3: 可投产

| ID | WBS | Task | Type | Duration | Start | Finish | Predecessors | Complete | Remaining | Total slack | Free slack | Constraint |
| --- | --- | --- | --- | --- | --- | --- | --- | --- | --- | --- | --- | --- |
| 25 | 1.5 | **结构-1组固定sipm板套筒、PCB板外形结构约束** |  | 108d? | 2026-03-30 A | 2026-07-16 |  | 64% | 39.27d? | 142d | 55d |  |
| 26 | 1.5.1 | SiPM板结构dxf |  | 5d | 2026-03-30 A | 2026-04-03 A |  | 100% |  |  |  |  |
| 27 | 1.5.2 | FEB板结构dxf |  | 9d | 2026-06-25 A | 2026-07-07 A | 9SF | 100% |  |  |  |  |
| 28 | 1.5.3 | MB1/2板结构dxf |  | 1d? | 2026-07-15 | 2026-07-16 | 15SF |  |  | 142d |  |  |
| 29 | 1.5.4 | 电源板板结构dxf |  | 7d? | 2026-07-03 | 2026-07-10 | 21SF |  |  | 148d |  |  |
| 30 | 1.6 | 电性件软件代码实现 |  | 30d | 2026-08-10 | 2026-09-08 | 73 |  |  | 87d | 0d | start no earlier than 2026-07-20 |
| 31 | 1.7 | 电性件测试与联试 |  | 22d | 2026-09-09 | 2026-09-30 | 2, 7, 13, 19, 25, 30 |  |  | 87d | 0d |  |
| 32 | 1.8 | 电性件交付总体 |  | 1d | 2026-10-01 | 2026-10-01 | 31 |  |  | 87d |  |  |
| 34 | 2 | **结构热控件** |  | 217d? | 2026-05-25 A | 2026-12-27 |  |  | 216.29d? | 0d |  |  |
| 35 | 2.1 | **结构热摸底件投产(含模具、1蜂窝板、1套筒)** |  | 116d? | 2026-05-25 | 2026-09-17 |  |  |  | 0d |  |  |
| 36 | 2.1.1 | 蜂窝板合同已签，正在投产 | manual | 116d | 2026-05-25 | 2026-09-17 |  |  |  |  |  |  |
| 37 | 2.1.2 | 套筒补充合同正在进行，开始加工模具 | manual | 1d? | 2026-09-17 | 2026-09-17 |  |  |  |  |  |  |
| 38 | 2.2 | **结构件投产** |  | 194d? | 2026-06-17 A | 2026-12-27 |  | 1% | 192.97d? | 0d |  |  |
| 39 | 2.2.1 | 完成预备会 | manual | 1d | 2026-06-17 A | 2026-06-17 A |  | 100% |  |  |  |  |
| 40 | 2.2.2 | **招标文件修改，提交招标公司修改确认** |  | 25d? | 2026-06-18 | 2026-07-12 |  |  |  |  |  |  |
| 41 | 2.2.2.1 | 招标文件更改 | manual | 9d | 2026-06-18 | 2026-06-26 | 39 |  |  |  |  |  |
| 42 | 2.2.2.2 | 财务处、招标公司确认 |  | 10d? | 2026-06-27 | 2026-07-06 | 41 |  |  | 6d |  |  |
| 43 | 2.2.3 | 公开招标(PSD&SCD 高能所与紫台一起) |  | 30d | 2026-07-13 | 2026-08-11 | 40 |  |  | 0d |  |  |
| 44 | 2.2.4 | 厂家生产 |  | 105d | 2026-08-12 | 2026-11-24 | 43 |  |  | 0d |  |  |
| 45 | 2.2.5 | 装配 |  | 22d | 2026-11-25 | 2026-12-16 | 44 |  |  | 0d |  |  |
| 46 | 2.2.6 | 应力筛选 |  | 10d | 2026-12-17 | 2026-12-26 | 45 |  |  | 0d |  |  |
| 47 | 2.2.7 | 交付总体 |  | 1d | 2026-12-27 | 2026-12-27 | 46 |  |  | 0d |  |  |
| 50 | 3 | **子系统初样设计评审** |  | 61d? | 2026-06-01 A | 2026-07-31 |  | 44% | 34d? | 149d |  |  |
| 51 | 3.1 | 电性件IDS | manual | 1d | 2026-06-16 A | 2026-06-16 A |  | 100% |  |  |  |  |
| 52 | 3.2 | 六性试验规划 | manual | 7d | 2026-06-29 A | 2026-07-05 A |  | 100% |  |  |  |  |
| 53 | 3.3 | 塑闪封装要求讨论 | manual | 6d | 2026-06-29 A | 2026-07-04 A |  | 100% |  |  |  |  |
| 54 | 3.4 | 标定实验规划 | manual | 5d | 2026-07-01 A | 2026-07-05 A |  | 100% |  |  |  |  |
| 55 | 3.5 | 低等级进口元器件、原材料报告 | manual | 35d | 2026-06-01 A | 2026-07-05 A |  | 100% |  |  |  |  |
| 56 | 3.6 | 力复核 | manual | 20d | 2026-06-30 | 2026-07-19 |  |  |  |  |  |  |
| 57 | 3.7 | 热复核 | manual | 33d | 2026-06-29 | 2026-07-31 |  |  |  |  |  |  |
| 58 | 3.8 | 初样设计文档编写 | manual | 13d | 2026-07-07 | 2026-07-19 |  |  |  |  |  |  |
| 59 | 3.9 | 子系统初样设计评审 |  | 1d? | 2026-07-20 | 2026-07-20 | 52, 53, 54, 56 |  |  | 160d |  |  |

| ID | WBS | Task | Type | Duration | Start | Finish | Predecessors | Complete | Remaining | Total slack | Free slack | Constraint | Text1 |
| --- | --- | --- | --- | --- | --- | --- | --- | --- | --- | --- | --- | --- | --- |
| 61 | 4 | **子系统软件设计评审** |  | 47d? | 2026-06-15 A | 2026-07-31 |  | 3% | 45.48d? | 0d |  |  |  |
| 62 | 4.1 | 软件任务书更新 | manual | 1d | 2026-06-15 A | 2026-06-15 A |  | 100% |  |  |  |  |  |
| 63 | 4.2 | 需求分析阶段文档编写 | manual | 29d | 2026-07-03 | 2026-07-31 |  |  |  |  |  |  |  |
| 66 | 5 | **塑闪筛选平台** |  | 176d? | 2026-03-17 A | 2026-09-08 |  | 35% | 114.31d? | 110d |  |  |  |
| 67 | 5.1 | SiPM采购 | manual | 68d | 2026-03-17 A | 2026-05-23 A |  | 100% |  |  |  |  |  |
| 68 | 5.2 | **miniPSD数据传输** |  | 56d? | 2026-06-15 | 2026-08-09 |  |  |  | 0d |  |  |  |
| 69 | 5.2.1 | miniPSD-2ram科学数据传输 | manual | 10d? | 2026-06-15 | 2026-06-24 |  |  |  |  |  |  | 王子乾 |
| 70 | 5.2.2 | miniPSD-4RAM科学数据传输 |  | 7d? | 2026-06-25 | 2026-07-01 | 69 |  |  | 87d | 0d |  | 王子乾 |
| 71 | 5.2.3 | SiPM板与miniPSD转接柔性板设计、投板 | manual | 21d? | 2026-07-13 | 2026-08-02 |  |  |  |  |  |  | 张凡 |
| 72 | 5.2.4 | ASIC配置数据读取 |  | 9d? | 2026-07-02 | 2026-07-10 | 70 |  |  | 87d | 0d |  | 王子乾 |
| 73 | 5.2.5 | 预触发改造--触发效率测试 |  | 30d | 2026-07-11 | 2026-08-09 | 72 |  |  | 87d | 0d |  | 王子乾 |
| 74 | 5.3 | ASIC电装 |  | 3d | 2026-07-11 | 2026-07-13 | 72 |  |  | 132d | 0d |  | 张凡 |
| 75 | 5.4 | 触发探测器与miniPSD采数测试 |  | 5d | 2026-07-14 | 2026-07-18 | 74 |  |  | 132d | 22d |  |  |
| 76 | 5.5 | 触发探测器用miniPSD/插件测试：触发信号输出 |  | 5d? | 2026-07-29 | 2026-08-03 | 77SF |  |  | 117d | 7d |  | 郭东亚 |
| 77 | 5.6 | 塑闪封装 |  | 5d? | 2026-08-03 | 2026-08-07 | 71 |  |  | 111d | 0d |  | 光电院 |
| 78 | 5.7 | 塑闪使用miniPSD读出 |  | 1d? | 2026-08-08 | 2026-08-08 | 77 |  |  | 111d | 1d |  |  |
| 79 | 5.8 | 触发效率测试 |  | 30d | 2026-08-10 | 2026-09-08 | 74, 75, 76, 77, 78, 68 |  |  | 110d |  |  |  |
| 82 | 6 | **SiPM筛选平台改造-PCB电装与样片测试** |  | 67d? | 2026-05-26 A | 2026-07-31 |  | 55% | 30d? | 0d |  |  |  |
| 83 | 6.1 | SiPM筛选母板、子板改造 | manual | 25d | 2026-05-26 A | 2026-06-19 A |  | 100% |  |  |  |  |  |
| 84 | 6.2 | SiPM裸片底座设计 | manual | 5d | 2026-06-22 A | 2026-06-26 A |  | 100% |  |  |  |  |  |
| 85 | 6.3 | SiPM裸片底座加工 |  | 1d | 2026-06-30 A | 2026-06-30 A |  | 100% |  |  |  | finish no earlier than 2026-06-30 |  |
| 86 | 6.4 | 标定SiPM 3D模型设计 | manual | 5d | 2026-06-22 A | 2026-06-26 A |  | 100% |  |  |  |  |  |
| 87 | 6.5 | 标定SiPM 3D模型加工 |  | 1d | 2026-06-30 A | 2026-06-30 A |  | 100% |  |  |  | finish no earlier than 2026-06-30 |  |
| 88 | 6.6 | SiPM裸片测试 | manual | 30d? | 2026-07-02 | 2026-07-31 |  |  |  |  |  |  |  |

Notes:
- 63: 《软件需求规格说明》、《软件配置项测试计划》、《软件开发计划》、《软件质量保证计划》、《软件配置管理计划》

| ID | WBS | Task | Type | Duration | Start | Finish | Predecessors | Complete | Remaining | Total slack | Free slack |
| --- | --- | --- | --- | --- | --- | --- | --- | --- | --- | --- | --- |
| 91 | 7 | **招标相关** |  | 183d? | 2026-06-26 A | 2026-12-25 |  | 2% | 178.63d? | 2d |  |
| 92 | 7.1 | **ASIC招标文件(与PD一起)** |  | 8d? | 2026-06-26 A | 2026-07-03 |  | 89% | 0.89d? | 0d |  |
| 93 | 7.1.1 | 招标文件讨论 | manual | 8d | 2026-06-26 A | 2026-07-03 A |  | 100% |  |  |  |
| 94 | 7.1.2 | 招标预备会-CALO进度安排 | manual | 1d? | 2026-06-26 | 2026-06-26 |  |  |  |  |  |
| 95 | 7.2 | **SiPM招标** |  | 167d | 2026-07-07 | 2026-12-20 |  |  |  | 0d |  |
| 96 | 7.2.1 | 文件准备 | manual | 4d | 2026-07-07 | 2026-07-10 |  |  |  |  |  |
| 97 | 7.2.2 | 招标文件讨论 | manual | 1d | 2026-07-13 | 2026-07-13 |  |  |  |  |  |
| 98 | 7.2.3 | 招标预备会 | manual | 4d | 2026-07-14 | 2026-07-17 |  |  |  |  |  |
| 99 | 7.2.4 | 招标 | manual | 32d | 2026-07-22 | 2026-08-22 |  |  |  |  |  |
| 100 | 7.2.5 | 到货 |  | 120d | 2026-08-23 | 2026-12-20 | 99 |  |  | 7d |  |
| 101 | 7.3 | **塑闪招标** |  | 165d | 2026-07-14 | 2026-12-25 |  |  |  | 0d |  |
| 102 | 7.3.1 | 文件准备 | manual | 7d | 2026-07-14 | 2026-07-20 |  |  |  |  |  |
| 103 | 7.3.2 | 招标文件讨论 |  | 1d | 2026-07-21 | 2026-07-21 | 102 |  |  | 2d | 0d |
| 104 | 7.3.3 | 招标预备会 |  | 7d | 2026-07-22 | 2026-07-28 | 103 |  |  | 2d | 0d |
| 105 | 7.3.4 | 招标 |  | 30d | 2026-07-29 | 2026-08-27 | 104 |  |  | 2d | 0d |
| 106 | 7.3.5 | 到货 |  | 120d | 2026-08-28 | 2026-12-25 | 105 |  |  | 2d |  |
